# Immeuble Méditerranée

Schedule from MS Project, 2016-02-15 to 2016-06-01, status date 2016-02-26, 7 hours a day, costs in €, A marks actual dates.

## Calendars

- Standard: Mon-Fri 09:00-12:00, 13:00-17:00; Sat-Sun off.

## Resources

| Resource | Group | Rate | Cost per use |
| --- | --- | --- | --- |
| NASHITA Laure | EQ01 | 25 |  |
| REGIO Mathias |  |  |  |
| Electronicien | OUV |  |  |
| Mécanicien | OUV |  |  |
| Contrôleur DC/DC | MAT |  |  |
| Onduleur SP1021 | MAT |  | 700 |
| DUPUIS Thomas |  |  |  |

## Schedule

| ID | WBS | Task | Type | Duration | Start | Finish | Predecessors | Complete | Remaining | Baseline start | Baseline finish | Baseline duration | Total slack | Free slack | Constraint | Resources | Work | Actual work | Cost | Baseline cost | Actual cost | Chemin critique |
| --- | --- | --- | --- | --- | --- | --- | --- | --- | --- | --- | --- | --- | --- | --- | --- | --- | --- | --- | --- | --- | --- | --- |
| 1 | 1 | Signature des contrats | milestone | 0d | 2016-02-15 | 2016-02-15 |  |  |  | 2016-02-15 | 2016-02-15 |  | 66.57d | 1d |  |  |  |  |  |  |  | Pas de variance |
| 2 | 2 | **Visite de chantier** |  | 11.43d | 2016-02-16 | 2016-03-02 |  |  |  | 2016-02-16 | 2016-02-16 | 1.14d | 65.57d |  |  |  |  |  |  |  |  | Variance de fin non critique |
| 3 | 2.1 | Visite de chantier 1 |  | 1.14d | 2016-02-16 | 2016-02-17 | 1 |  |  | 2016-02-16 | 2016-02-16 | 1.14d | 65.57d | 0d | start no earlier than 2016-02-16 |  |  |  |  |  |  | Variance de fin non critique |
| 4 | 2.2 | Visite de chantier 2 |  | 1.14d | 2016-02-17 | 2016-02-18 | 3 |  |  | 2016-02-16 | 2016-02-16 | 1.14d | 65.57d | 0d | start no earlier than 2016-02-16 |  |  |  |  |  |  | Variance de fin non critique |
| 5 | 2.3 | Visite de chantier 3 |  | 1.14d | 2016-02-18 | 2016-02-19 | 4 |  |  | 2016-02-16 | 2016-02-16 | 1.14d | 65.57d | 0d | start no earlier than 2016-02-16 |  |  |  |  |  |  | Variance de fin non critique |
| 6 | 2.4 | Visite de chantier 4 |  | 1.14d | 2016-02-19 | 2016-02-22 | 5 |  |  | 2016-02-16 | 2016-02-16 | 1.14d | 65.57d | 0d | start no earlier than 2016-02-16 |  |  |  |  |  |  | Variance de fin non critique |
| 7 | 2.5 | Visite de chantier 5 |  | 1.14d | 2016-02-22 | 2016-02-23 | 6 |  |  | 2016-02-16 | 2016-02-16 | 1.14d | 65.57d | 0d | start no earlier than 2016-02-16 |  |  |  |  |  |  | Variance de fin non critique |
| 8 | 2.6 | Visite de chantier 6 |  | 1.14d | 2016-02-23 | 2016-02-24 | 7 |  |  | 2016-02-16 | 2016-02-16 | 1.14d | 65.57d | 0d | start no earlier than 2016-02-16 |  |  |  |  |  |  | Variance de fin non critique |
| 9 | 2.7 | Visite de chantier 7 |  | 1.14d | 2016-02-24 | 2016-02-25 | 8 |  |  | 2016-02-16 | 2016-02-16 | 1.14d | 65.57d | 0d | start no earlier than 2016-02-16 |  |  |  |  |  |  | Variance de fin non critique |
| 10 | 2.8 | Visite de chantier 8 |  | 1.14d | 2016-02-26 | 2016-02-29 | 9 |  |  | 2016-02-16 | 2016-02-16 | 1.14d | 65.57d | 0d | start no earlier than 2016-02-16 |  |  |  |  |  |  | Variance de fin non critique |
| 11 | 2.9 | Visite de chantier 9 |  | 1.14d | 2016-02-29 | 2016-03-01 | 10 |  |  | 2016-02-16 | 2016-02-16 | 1.14d | 65.57d | 0d | start no earlier than 2016-02-16 |  |  |  |  |  |  | Variance de fin non critique |
| 12 | 2.10 | Visite de chantier 10 |  | 1.14d | 2016-03-01 | 2016-03-02 | 11 |  |  | 2016-02-16 | 2016-02-16 | 1.14d | 65.57d |  | start no earlier than 2016-02-16 |  |  |  |  |  |  | Variance de fin non critique |
| 13 | 3 | **Travaux préparatoires** |  | 25d | 2016-02-15 A | 2016-03-18 |  | 60% | 10d | 2016-02-15 | 2016-03-18 | 27.43d |  |  |  |  | 280h | 210h | 4,375 |  | 2,625 | Variance de fin non critique |
| 14 | 3.1 | Implantation géomètre |  | 5d | 2016-02-15 A | 2016-02-19 A |  | 100% |  | 2016-02-15 | 2016-02-19 | 5.71d |  |  |  | NASHITA Laure; REGIO Mathias | 70h | 70h | 875 |  | 875 | Pas de variance |
| 15 | 3.2 | Nettoyage / débroussaillage du terrain |  | 5d | 2016-02-22 A | 2016-02-26 A | 14 | 100% |  | 2016-02-22 | 2016-02-26 | 5.71d |  |  |  | REGIO Mathias; NASHITA Laure | 70h | 70h | 875 |  | 875 | Pas de variance |
| 16 | 3.3 | Evacuation des terres excédentaires |  | 5d | 2016-02-29 A | 2016-03-04 A | 15 | 100% |  | 2016-02-29 | 2016-03-04 | 5.71d |  |  |  | DUPUIS Thomas; NASHITA Laure | 70h | 70h | 875 |  | 875 | Pas de variance |
| 17 | 3.4 | Terrassements |  | 10d | 2016-03-07 | 2016-03-18 | 16 |  |  | 2016-03-04 | 2016-03-18 | 11.43d | 53d |  |  | NASHITA Laure | 70h |  | 1,750 |  |  | Variance de fin non critique |
| 18 | 4 | **Fondations** |  | 13d | 2016-02-22 A | 2016-03-09 |  | 38% | 8d | 2016-03-18 | 2016-04-01 | 12.57d | -1d | 0d |  |  | 126h | 35h | 2,275 |  | 875 | Pas de variance |
| 19 | 4.1 | Semelles |  | 3d | 2016-02-22 A | 2016-02-24 A | 14 | 100% |  | 2016-03-18 | 2016-03-21 | 2.29d |  |  |  | NASHITA Laure | 21h | 21h | 525 |  | 525 | Pas de variance |
| 20 | 4.2 | Dalle sous-sol |  | 5d | 2016-02-25 A | 2016-03-02 | 19 | 40% | 3d | 2016-03-21 | 2016-03-26 | 5.71d | -1d | 0d |  | NASHITA Laure | 35h | 14h | 875 |  | 350 | Pas de variance |
| 21 | 4.3 | Murs sous-sol |  | 5d | 2016-03-03 | 2016-03-09 | 20 |  |  | 2016-03-28 | 2016-04-01 | 5.71d | -1d | 0d |  | Mécanicien; NASHITA Laure | 70h |  | 875 |  |  | Pas de variance |
| 22 | 5 | **Gros oeuvre** |  | 45d | 2016-03-10 | 2016-05-11 |  |  |  | 2016-04-01 | 2016-05-12 | 33.14d | -1d | 0d |  |  | 140h |  | 700 | 700 |  | Pas de variance |
| 23 | 5.1 | Elévation murs, planchers et toitures |  | 20d | 2016-03-10 | 2016-04-06 | 21 |  |  | 2016-04-01 | 2016-04-22 | 17.14d | -1d | 0d |  |  |  |  |  |  |  | Pas de variance |
| 24 | 5.2 | Planchers |  | 15d | 2016-04-07 | 2016-04-27 | 23 |  |  | 2016-04-22 | 2016-04-28 | 5.71d | 0d |  |  |  |  |  |  |  |  | Pas de variance |
| 25 | 5.3 | Menuiseries extérieures |  | 10d | 2016-04-28 | 2016-05-11 | 24 |  |  | 2016-04-29 |  | 11.43d | 0d |  |  | Onduleur SP1021; Mécanicien | 140h |  | 700 | 700 |  | Pas de planification de référence |
| 26 | 5.4 | Bâtiment hors d'eau, hors d'air | milestone | 0d | 2016-05-11 | 2016-05-11 | 25 |  |  | 2016-05-12 | 2016-05-12 |  | 0d |  |  |  |  |  |  |  |  | Pas de variance |

| ID | WBS | Task | Duration | Start | Finish | Predecessors | Baseline start | Baseline finish | Baseline duration | Total slack | Free slack | Deadline | Chemin critique |
| --- | --- | --- | --- | --- | --- | --- | --- | --- | --- | --- | --- | --- | --- |
| 27 | 6 | **Traitement extérieur des murs** | 15d | 2016-05-12 | 2016-06-01 |  | 2016-05-13 | 2016-06-02 | 17.14d | 0d |  |  | Pas de variance |
| 28 | 6.1 | Bardage | 10d | 2016-05-12 | 2016-05-25 | 26 | 2016-05-13 |  | 11.43d | 0d |  |  | Pas de planification de référence |
| 29 | 6.2 | Enduit | 5d | 2016-05-26 | 2016-06-01 | 28 | 2016-05-27 | 2016-06-02 | 5.71d | 0d |  |  | Pas de variance |
| 30 | 7 | **Seconde oeuvre** | 6d | 2016-04-07 | 2016-04-14 |  | 2016-04-22 | 2016-04-28 | 5.71d | -1d | 0d |  | Pas de variance |
| 31 | 7.1 | **Chauffage, climatisation, plomberie** | 6d | 2016-04-07 | 2016-04-14 |  | 2016-04-22 | 2016-04-28 | 5.71d | -1d | 0d |  | Pas de variance |
| 32 | 7.1.1 | Chauffage | 6d | 2016-04-07 | 2016-04-14 | 23 | 2016-04-22 | 2016-04-28 | 5.71d | -1d | 0d | 2016-04-13 | Pas de variance |
| 33 | 7.1.2 | Climatisation | 5d | 2016-04-07 | 2016-04-13 | 32SS | 2016-04-22 | 2016-04-28 | 5.71d | 35d | 0d |  | Pas de variance |
| 34 | 7.1.3 | Plomberie | 5d | 2016-04-07 | 2016-04-13 | 33SS | 2016-04-22 | 2016-04-28 | 5.71d | 35d |  |  | Pas de variance |
